Schedule from Planner, 2006-01-20 to 2006-07-10.

## Calendars

- Default: Mon-Sat 08:00-12:00, 13:00-17:00; Sun off. Exceptions (off unless hours are given): 2006-03-24 to 2006-03-25 08:00-12:00, 13:00-17:00, 2006-03-27 to 2006-04-01 08:00-12:00, 13:00-17:00.

## Resources

| Resource | Group | Notes |
| --- | --- | --- |
| Andrew Greenberg |  |  |
| Jacob Davidson | students |  |
| Glenn LeBrasseur | students |  |
| Sarah Bailey | students | On vacation from 03/23 (evening) to 01/02 (evening). |

## Schedule

| ID | WBS | Task | Type | Duration | Start | Finish | Predecessors | Constraint | Work |
| --- | --- | --- | --- | --- | --- | --- | --- | --- | --- |
| 1 | 1 | **Project Proposal Presentation** |  |  | 2006-01-20 | 2006-02-02 |  | must start on 2006-02-03 | 96h |
| 2 | 1.1 | Rough Draft ready for Andrew |  |  | 2006-01-20 | 2006-01-25 |  | start no earlier than 2006-01-20 | 40h |
| 3 | 1.2 | Rough Draft to Faust |  |  | 2006-01-26 | 2006-01-28 | 2 |  | 24h |
| 4 | 1.3 | work out schedule details w/ Andrew |  |  | 2006-01-25 | 2006-01-25 |  | must start on 2006-01-25 | 8h |
| 5 | 1.4 | project schedule |  |  | 2006-01-26 | 2006-01-26 | 4 |  | 8h |
| 6 | 1.5 | finalize written proposal |  |  | 2006-01-30 | 2006-01-31 | 5, 3, 2 |  | 16h |
| 7 | 1.6 | presentation slides/roles |  |  | 2006-01-30 | 2006-01-31 | 3 | start no earlier than 2006-01-27 | 16h |
| 8 | 1.7 | presentation dry run | milestone | 0d | 2006-02-01 | 2006-02-01 | 7, 6 | must start on 2006-02-01 |  |
| 9 | 1.8 | proposal presentation | milestone | 0d | 2006-02-03 | 2006-02-03 | 8 | must start on 2006-02-03 |  |
| 10 | 2 | **Choose Microcontroller** |  |  | 2006-02-03 | 2006-03-24 |  | start no earlier than 2006-02-04 | 344h |
| 11 | 2.1 | discussion |  |  | 2006-02-03 | 2006-03-08 | 1 |  | 232h |
| 12 | 2.2 | order microcontroller |  |  | 2006-03-09 | 2006-03-24 | 11 |  | 112h |
| 13 | 3 | Spring break |  |  | 2006-03-25 | 2006-04-01 | 10 |  | 56h |
| 14 | 4 | block diagram upgrade |  |  | 2006-04-03 | 2006-04-08 | 13, 10, 11 | start no earlier than 2006-02-08 | 48h |
| 15 | 5 | **detailed schematic** |  |  | 2006-04-10 | 2006-04-25 | 11, 14 |  | 112h |
| 16 | 5.1 | power supply block |  |  | 2006-04-10 | 2006-04-25 |  |  | 112h |
| 17 | 5.2 | microcontroller block |  |  | 2006-04-10 | 2006-04-25 |  |  | 112h |
| 18 | 5.3 | interface block |  |  | 2006-04-10 | 2006-04-25 |  |  | 112h |
| 19 | 6 | Schematics design review + design interation |  |  | 2006-04-26 | 2006-04-28 | 15, 14, 10 | start no earlier than 2006-03-08 | 24h |
| 20 | 7 | **final layout** |  |  | 2006-04-29 | 2006-05-09 | 19 |  | 72h |
| 21 | 7.1 | Package list + check availability |  |  | 2006-04-29 | 2006-05-04 |  |  | 40h |
| 22 | 7.2 | board layout |  |  | 2006-04-29 | 2006-05-06 |  |  | 56h |
| 23 | 7.3 | produce and check Gerbers |  |  | 2006-05-08 | 2006-05-08 | 22 |  | 8h |
| 24 | 7.4 | validate |  |  | 2006-05-09 | 2006-05-09 | 23 |  | 8h |
| 25 | 8 | Board design done | milestone | 0d | 2006-05-09 | 2006-05-09 | 20 |  |  |
| 26 | 9 | Order components |  |  | 2006-05-10 | 2006-05-17 | 25 |  | 56h |
| 27 | 10 | FAB of board |  | 4d | 2006-05-18 | 2006-05-22 | 26, 25 |  | 24h |
| 28 | 11 | stuff board |  |  | 2006-05-23 | 2006-05-30 | 27 |  | 56h |
| 29 | 12 | Prototype constructed | milestone | 0d | 2006-05-30 | 2006-05-30 | 28 |  |  |

| ID | WBS | Task | Type | Duration | Start | Finish | Predecessors | Work |
| --- | --- | --- | --- | --- | --- | --- | --- | --- |
| 30 | 13 | **customize firmware** |  |  | 2006-05-10 | 2006-06-06 | 25 | 192h |
| 31 | 13.1 | queue scheme |  |  | 2006-05-10 | 2006-05-13 |  | 32h |
| 32 | 13.2 | interrupt handler |  |  | 2006-05-15 | 2006-05-25 | 31 | 80h |
| 33 | 13.3 | message handler |  |  | 2006-05-26 | 2006-06-02 | 32 | 56h |
| 34 | 13.4 | flash firmware |  |  | 2006-06-03 | 2006-06-06 | 33, 29 | 24h |
| 35 | 14 | Firmware demo (first LED blink over CAN) | milestone | 0d | 2006-06-06 | 2006-06-06 | 30, 29 |  |
| 36 | 15 | **Test prototype** |  |  | 2006-05-31 | 2006-06-01 | 29 | 16h |
| 37 | 15.1 | voltage tests |  |  | 2006-05-31 | 2006-05-31 | 29 | 4h |
| 38 | 15.2 | temperature tests? |  |  | 2006-05-31 | 2006-05-31 | 37 | 4h |
| 39 | 15.3 | power consumption test |  |  | 2006-06-01 | 2006-06-01 | 38 | 4h |
| 40 | 15.4 | noise test (RF) |  |  | 2006-06-01 | 2006-06-01 | 39 | 4h |
| 41 | 16 | **measure bus performance** |  |  | 2006-06-07 | 2006-06-15 | 36, 30 | 64h |
| 42 | 16.1 | single channel bus test |  |  | 2006-06-07 | 2006-06-10 |  | 32h |
| 43 | 16.2 | multiple (two?) channel bus test |  |  | 2006-06-12 | 2006-06-15 | 42 | 32h |
| 44 | 17 | white paper |  |  | 2006-06-16 | 2006-07-10 | 41, 25 | 168h |
